# 三码合一项目开发计划

Schedule from MS Project, 2022-03-03 to 2022-03-08.

## Calendars

- 标准: Mon-Fri 08:00-12:00, 13:00-17:00; Sat-Sun off.

## Resources

| Resource |
| --- |
| 袁顺生 |
| 颜彬彬 |
| 100% |
| 周泽雨 |
| 胡圣杰 |
| 崔晓成&高宏博 |
| 陆仲夏 |
| 郭彦兵 |
| 柴永强 |

## Schedule

| ID | WBS | Task | Type | Duration | Start | Finish | Resources | Work |
| --- | --- | --- | --- | --- | --- | --- | --- | --- |
| 1 | 1 | **三码合一** |  | 3d? | 2022-03-03 | 2022-03-07 |  | 352h |
| 2 | 1.1 | **条零** |  | 4d? | 2022-03-03 | 2022-03-08 |  | 224h |
| 3 | 1.1.1 | **现场子系统** |  | 2d? | 2022-03-03 | 2022-03-04 |  | 168h |
| 4 | 1.1.1.1 | 算法 | manual | 2d | 2022-03-03 | 2022-03-04 | 崔晓成&高宏博 | 16h |
| 5 | 1.1.1.2 | **关联管理** |  | 2d | 2022-03-03 | 2022-03-04 | 柴永强 | 16h |
| 6 | 1.1.1.2.1 | 关系入库 | manual | 2d | 2022-03-03 | 2022-03-04 |  |  |
| 7 | 1.1.1.2.2 | 查看界面 | manual | 2d | 2022-03-03 | 2022-03-04 |  |  |
| 8 | 1.1.1.3 | context | manual | 3d | 2022-03-03 | 2022-03-07 | 柴永强 | 24h |
| 9 | 1.1.1.4 | **订单管理** |  | 3d? | 2022-03-03 | 2022-03-07 | 颜彬彬 | 24h |
| 10 | 1.1.1.4.1 | 订单和数据下拉 | manual | 3d | 2022-03-03 | 2022-03-07 |  |  |
| 11 | 1.1.1.4.2 | 订单关联条码批次上报 | manual | 3d | 2022-03-03 | 2022-03-07 |  |  |
| 12 | 1.1.1.5 | 批次上报 | manual | 2d | 2022-03-03 | 2022-03-04 | 胡圣杰 | 16h |
| 13 | 1.1.1.6 | **主页** |  | 2d | 2022-03-03 | 2022-03-04 |  | 32h |
| 14 | 1.1.1.6.1 | 页面设计 | manual | 2d | 2022-03-03 | 2022-03-04 | 陆仲夏 | 16h |
| 15 | 1.1.1.6.2 | 页面开发 | manual | 2d | 2022-03-03 | 2022-03-04 | 郭彦兵 | 16h |
| 16 | 1.1.1.7 | 注册界面，相机plc配置界面 | manual | 2d | 2022-03-03 | 2022-03-04 | 郭彦兵 | 16h |
| 17 | 1.1.1.8 | 主页路由切换 | manual | 3d | 2022-03-03 | 2022-03-07 | 胡圣杰 | 24h |
| 18 | 1.1.1.9 | 品规，排班，班组 | manual | 1d | 2022-03-03 | 2022-03-03 |  |  |
| 19 | 1.1.2 | **厂级子系统** |  | 3d? | 2022-03-03 | 2022-03-07 |  | 56h |
| 20 | 1.1.2.1 | 关联关系管理 | manual | 2d | 2022-03-03 | 2022-03-04 | 颜彬彬 | 16h |
| 21 | 1.1.2.2 | 订单管理 | manual | 1d | 2022-03-03 | 2022-03-03 | 颜彬彬 | 8h |
| 22 | 1.1.2.3 | **报表微服务** |  | 4d? | 2022-03-03 | 2022-03-08 | 周泽雨 | 32h |
| 23 | 1.1.2.3.1 | 告警统计 | manual | 4d | 2022-03-03 | 2022-03-08 |  |  |
| 24 | 1.1.2.3.2 | 订单数量统计 | manual | 4d | 2022-03-03 | 2022-03-08 |  |  |
| 25 | 1.1.2.3.3 | 条数量统计 | manual | 4d | 2022-03-03 | 2022-03-08 |  |  |

| ID | WBS | Task | Type | Duration | Start | Finish | Resources | Work |
| --- | --- | --- | --- | --- | --- | --- | --- | --- |
| 26 | 1.2 | **盒条件** |  | 1d? | 2022-03-03 | 2022-03-03 |  | 96h |
| 27 | 1.2.1 | **现场子系统** |  | 0d? | 2022-03-03 | 2022-03-03 |  | 16h |
| 28 | 1.2.1.1 | 功能测试，bug记录 | manual | 1d | 2022-03-03 | 2022-03-03 | 郭彦兵 | 8h |
| 29 | 1.2.1.2 | 人工作业 | manual | 1d | 2022-03-03 | 2022-03-03 | 袁顺生 | 8h |
| 30 | 1.2.2 | **厂级子系统** |  | 1d? | 2022-03-03 | 2022-03-03 |  | 80h |
| 31 | 1.2.2.1 | **人工作业** |  | 1d? | 2022-03-03 | 2022-03-03 |  | 24h |
| 32 | 1.2.2.1.1 | 反关联(解绑记录表) | manual | 3d | 2022-03-03 | 2022-03-07 | 袁顺生 | 24h |
| 33 | 1.2.2.2 | **异常管理** |  | 0d? | 2022-03-03 | 2022-03-03 | 周泽雨 | 24h |
| 34 | 1.2.2.2.1 | mq告警 | manual | 1d | 2022-03-03 | 2022-03-03 | 胡圣杰 | 8h |
| 35 | 1.2.2.2.2 | 数据关联告警 | manual | 1d | 2022-03-03 | 2022-03-03 | 颜彬彬 | 8h |
| 36 | 1.2.2.2.3 | 接收告警 | manual | 1d | 2022-03-03 | 2022-03-03 | 周泽雨 | 8h |
| 37 | 1.2.2.3 | 报表微服务 | manual | 1d | 2022-03-03 | 2022-03-03 | 颜彬彬 | 8h |
| 38 | 1.2.2.4 | **子系统管理** |  | 2d | 2022-03-03 | 2022-03-04 | 周泽雨 | 16h |
| 39 | 1.2.2.4.1 | 详情界面展示告警 | manual | 2d | 2022-03-03 | 2022-03-04 |  |  |
| 40 | 1.2.2.5 | 微服务部署 | manual | 1d | 2022-03-03 | 2022-03-03 | 胡圣杰 | 8h |
| 41 | 1.3 | **PDA** |  | 0d? | 2022-03-03 | 2022-03-03 |  | 32h |
| 42 | 1.3.1 | **盒条件** |  | 0d? | 2022-03-03 | 2022-03-03 |  | 16h |
| 43 | 1.3.1.1 | 页面设计 | manual | 2d | 2022-03-03 | 2022-03-04 | 陆仲夏 | 16h |
| 44 | 1.3.2 | **条零** |  | 0d? | 2022-03-03 | 2022-03-03 |  | 8h |
| 45 | 1.3.2.1 | 页面设计 | manual | 1d | 2022-03-03 | 2022-03-03 | 陆仲夏 | 8h |
| 46 | 1.3.3 | 代码上传git | manual | 1d | 2022-03-03 | 2022-03-03 | 胡圣杰 | 8h |
